# Μεταφορά νερού_new

Schedule from MS Project, 2002-01-01 to 2004-01-01, 24 hours a day.
NAMA SA

## Calendars

- 24 Hours: Mon-Sun 00:00-24:00.

## Resources

| Resource |
| --- |
| Εργοδότης |
| Προιστάμενη Αρχή |
| Διευθύνουσα Υπηρεσία |
| Γενικός Μελετητής |
| Αλλοι τοπικοί φορείς |
| Κύριος του Έργου |
| Γενικός Μελετητής(Ειδικός Συγκοινωνιολόγος) |
| Μελετήτής Οικονομολόγος |
| Δνση Χωροταξίας ΥΠΕΧΩΔΕ ή ΓΓ Περίφέρειας |
| Μελετητής Κτηματολογίου |
| ΥΠΕΧΩΔΕ/ Δ/νση Απαλλοτριώσεων (Τμήμα Δ12α) |
| ΥΠΕΧΩΔΕ/ Δ/νση Απαλλοτριώσεων (Τμήμα Δ12β) |
| Τμήμα Απαλλοτριώσεων Υπουργείου Οικονομικών |
| Δ/νση Προστασίας Δασών ΥΠΓΕ |
| Δ/σεις Δασών-Δασαρχεία |
| ΟΤΑ |
| Υπουργός ΠΕΧΩΔΕ |
| Υπουργός Γεωργίας |
| Υπουργός Οικονομικών |
| Εθνικό Τυπογραφείο |
| Αρμόδια ΔΟΥ |
| Τριμελής Επιτροπή |
| Κτηματική Υπηρεσία Νομού |
| Υποθηκοφυλάκιο |
| Νομικός Σύμβουλος του Κράτους ή Δικηγόρος του Δημοσίου |
| Αρμόδιο Μονομελές Πρωτοδικείο |
| Υπόλογος του Έργου |
| Ταμείο Παρακαταθηκών και Δανείων |
| Εφημερίδα της Κυβερνήσεως |
| Αστυνομικές Αρχές |
| Κτηματογράφος Μηχανικός |
| Γεν. Δ/ντης Υπουργείου Οικονομικών |
| Προιστάμενος Κτηματογραφείου |
| Τεχνική Υπηρεσία Υπουργείου Οικονομικών |
| Διακαιούχοι αποζημίωσης |
| Συμβούλιο Δημοσίων Έργων |

## Schedule

| ID | WBS | Task | Type | Duration | Start | Finish | Predecessors | Baseline start | Baseline finish | Baseline duration | Total slack | Free slack | Constraint | Resources | Work | Text1 |
| --- | --- | --- | --- | --- | --- | --- | --- | --- | --- | --- | --- | --- | --- | --- | --- | --- |
| 1 | 1 | Σύνταξη Κτηματολογίου |  | 150d | 2002-01-01 | 2002-05-31 |  | 2002-01-01 | 2002-02-28 | 58d | 0d |  |  | Κύριος του Έργου; Διευθύνουσα Υπηρεσία; Μελετητής Κτηματολογίου; ΥΠΕΧΩΔΕ/ Δ/νση Απαλλοτριώσεων (Τμήμα Δ12α); ΥΠΕΧΩΔΕ/ Δ/νση Απαλλοτριώσεων (Τμήμα Δ12β) | 9792h | 5Μ |
| 2 | 2 | Διαδικασία Κήρυξης Αναγκαστικής Απαλλοτριώσης |  | 153d | 2002-05-31 | 2002-10-31 | 1 | 2002-01-11 | 2002-01-11 | 0.33d? | 0d |  |  | Εργοδότης; ΥΠΕΧΩΔΕ/ Δ/νση Απαλλοτριώσεων (Τμήμα Δ12α); ΥΠΕΧΩΔΕ/ Δ/νση Απαλλοτριώσεων (Τμήμα Δ12β); Τμήμα Απαλλοτριώσεων Υπουργείου Οικονομικών; Δ/νση Προστασίας Δασών ΥΠΓΕ; Δ/σεις Δασών-Δασαρχεία; ΟΤΑ; Υπουργός ΠΕΧΩΔΕ; Υπουργός Γεωργίας; Υπουργός Οικονομικών; Εθνικό Τυπογραφείο | 3902.23h | 5Μ |
| 3 | 3 | **Διαδικασία Αποζημίωσης Απαλλοτριώσεων** |  | 426d | 2002-10-31 | 2003-12-31 | 2 | 2002-01-11 | 2002-01-11 | 0.33d? | 0d |  |  |  | 14101.5h | 14Μ |
| 4 | 3.1 | Κίνηση Δικαστικής Διαδικασίας - Εκτίμηση Αξίας Απαλλοτριωμένου Ακινήτου - Προδικασία |  | 102d | 2002-10-31 | 2003-02-10 |  | 2002-04-14 | 2002-05-15 | 31d | 0d |  |  | Εργοδότης [37.5%]; ΥΠΕΧΩΔΕ/ Δ/νση Απαλλοτριώσεων (Τμήμα Δ12α); Αρμόδια ΔΟΥ; Τριμελής Επιτροπή; Κτηματική Υπηρεσία Νομού; Υποθηκοφυλάκιο; Νομικός Σύμβουλος του Κράτους ή Δικηγόρος του Δημοσίου; Αρμόδιο Μονομελές Πρωτοδικείο | 4949.47h | 3.5Μ |
| 5 | 3.2 | Αναμονή για Δικάσιμο |  | 59d | 2003-02-10 | 2003-04-10 | 4 | 2002-05-15 | 2002-05-30 | 15d | 0d |  |  |  |  | 2Μ |
| 6 | 3.3 | Προσδιορισμός Αποζημίωσης |  | 144d | 2003-04-10 | 2003-09-01 | 5 | 2002-05-30 | 2002-06-15 | 16d | 0d |  |  | ΥΠΕΧΩΔΕ/ Δ/νση Απαλλοτριώσεων (Τμήμα Δ12α); Τμήμα Απαλλοτριώσεων Υπουργείου Οικονομικών; Κτηματική Υπηρεσία Νομού; Νομικός Σύμβουλος του Κράτους ή Δικηγόρος του Δημοσίου; Αρμόδιο Μονομελές Πρωτοδικείο | 3840h | 4.5Μ |
| 7 | 3.4 | Παρακατάθεση-Συντέλεση |  | 91d | 2003-09-01 | 2003-12-01 | 6 | 2002-06-15 | 2002-08-31 | 77d | 0d |  |  | Εργοδότης; ΥΠΕΧΩΔΕ/ Δ/νση Απαλλοτριώσεων (Τμήμα Δ12α); Τμήμα Απαλλοτριώσεων Υπουργείου Οικονομικών; Υπόλογος του Έργου; Ταμείο Παρακαταθηκών και Δανείων; Εφημερίδα της Κυβερνήσεως | 4784h | 3Μ |
| 8 | 3.5 | Κατάληψη |  | 30d | 2003-12-01 | 2003-12-31 | 7 | 2002-08-31 | 2002-08-31 | 33d | 0d |  |  | Αρμόδιο Μονομελές Πρωτοδικείο; Αστυνομικές Αρχές; Κτηματική Υπηρεσία Νομού | 528h | 1Μ |
| 9 | 4 | Εγκατάσταση Αναδόχου | milestone | 1d? | 2003-12-31 | 2004-01-01 | 3 |  |  |  | 0d |  |  |  |  | 0Μ |
| 10 | 5 | **Διαδικασία Αναγνώρισης Δικαιούχων** |  | 426d | 2002-11-01 | 2004-01-01 |  | 2002-08-31 | 2002-10-01 | 31d | 0.33d |  |  |  | 20352h | 13.5Μ |
| 11 | 5.1 | Διόρθωση Κτηματολογικών Στοιχείων - Κτηματογράφηση |  | 189d | 2002-11-01 | 2003-05-09 |  | 2002-10-01 | 2004-06-30 | 638d | 0.33d | 0d | start no earlier than 2002-11-01 | Κτηματική Υπηρεσία Νομού; Κτηματογράφος Μηχανικός; Γεν. Δ/ντης Υπουργείου Οικονομικών; Προιστάμενος Κτηματογραφείου; ΥΠΕΧΩΔΕ/ Δ/νση Απαλλοτριώσεων (Τμήμα Δ12α); Τμήμα Απαλλοτριώσεων Υπουργείου Οικονομικών; Τεχνική Υπηρεσία Υπουργείου Οικονομικών; Αρμόδιο Μονομελές Πρωτοδικείο; Κύριος του Έργου; Διακαιούχοι αποζημίωσης | 14256h | 6.5Μ |
| 12 | 5.2 | Αναμονή για Δικάσιμο |  | 60d | 2003-05-09 | 2003-07-08 | 11 | 2002-10-01 | 2004-06-30 | 638d | 0.33d | 0d |  |  |  | 2Μ |
| 13 | 5.3 | Αναγνώριση Δικαιούχου |  | 177d | 2003-07-08 | 2004-01-01 | 12 | 2002-10-01 | 2003-02-28 | 150d | 0.33d |  |  | Αρμόδιο Μονομελές Πρωτοδικείο; Κτηματική Υπηρεσία Νομού; ΥΠΕΧΩΔΕ/ Δ/νση Απαλλοτριώσεων (Τμήμα Δ12α); Τμήμα Απαλλοτριώσεων Υπουργείου Οικονομικών; Ταμείο Παρακαταθηκών και Δανείων; Διακαιούχοι αποζημίωσης | 6096h | 5.5Μ |
| 14 | 6 | Διαδικασία του άρθρου 7Α του Νόμου 2985/2002 |  | 151d | 2002-10-31 | 2003-03-31 | 3SS |  |  |  | 276d | 0d |  |  |  | 5Μ |
| 15 | 7 | Εγκατάσταση Αναδόχου | milestone | 1d? | 2003-03-31 | 2003-04-01 | 14 |  |  |  | 275d |  |  |  |  | 0Μ |
